# SUB PROYECTO A3 - CRONOGRAMA OFERTA - R02

Schedule from Primavera P6, 2023-05-02 to 2023-12-02, data date 2023-05-02.

## Calendars

- Calendario Lacramarca 7D-1T: Mon-Sun 07:00-12:00, 13:00-18:00.

## Resources

| Resource | Group |
| --- | --- |
| HH | labor |
| HM | equipment |
| EXCAVACIONES | material |
| RELLENOS | material |
| ENROCADOS | material |

## Schedule

| ID | WBS | Activity | Type | Duration | Start | Finish | Predecessors | Total float | Free float | Constraint |
| --- | --- | --- | --- | --- | --- | --- | --- | --- | --- | --- |
|  | 000 | **GENERALES** |  |  | 2023-05-02 | 2023-12-02 |  |  |  |  |
|  | M | **GESTION** |  |  | 2023-05-02 | 2023-05-02 |  |  |  |  |
|  | 10 | **CONTROL DE PROYECTOS** |  |  | 2023-05-02 | 2023-05-02 |  |  |  |  |
|  | 01 | **HITOS DE CONTROL** |  |  | 2023-05-02 | 2023-05-02 |  |  |  |  |
|  | 01 | **HITOS CLAVE** |  |  | 2023-05-02 | 2023-05-02 |  |  |  |  |
| M.10.01.01.11 |  | KOM | milestone | 0d | 2023-05-02 | 2023-05-02 |  | 0d |  |  |
|  | C | **CONSTRUCCION** |  |  | 2023-05-02 | 2023-12-02 |  |  |  |  |
|  | 90 | **TRABAJOS PRELIMINARES** |  |  | 2023-05-02 | 2023-12-02 |  |  |  |  |
|  | 02 | **COSTOS DEL CONTRATISTA GENERAL** |  |  | 2023-05-02 | 2023-05-17 |  |  |  |  |
|  | 01 | **MOVILIZACIÓN** |  |  | 2023-05-02 | 2023-05-17 |  |  |  |  |
| C.90.02.01.11 |  | Movilización inicial de equipos - Movimiento de Tierras |  | 16d | 2023-05-02 | 2023-05-17 | M.10.01.01.11 SS | 0d |  |  |
|  | 03 | **GASTOS GENERALES** |  |  | 2023-05-02 | 2023-12-02 |  |  |  |  |
| C.90.03.11 |  | Gastos Generales | level of effort | 215d | 2023-05-02 | 2023-12-02 | M.10.01.01.11 SS | 0d |  |  |
|  | 501 | **DEFENSAS RIBEREÑAS** |  |  | 2023-05-18 | 2023-12-02 |  |  |  |  |
|  | M | **GESTION** |  |  | 2023-05-18 | 2023-12-02 |  |  |  |  |
|  | 10 | **CONTROL DE PROYECTOS** |  |  | 2023-05-18 | 2023-12-02 |  |  |  |  |
|  | 01 | **HITOS DE CONTROL** |  |  | 2023-05-18 | 2023-12-02 |  |  |  |  |
|  | 02 | **HITOS PLANIFICADOS** |  |  | 2023-05-18 | 2023-12-02 |  |  |  |  |
| M.10.01.02.11 |  | Hito Planificado 1: Acceso al sitio | milestone | 0d | 2023-05-18 | 2023-05-18 | C.90.02.01.11 | 0d |  |  |
| M.10.01.02.12 |  | Hito Planificado 2: Inicio de excavación | milestone | 0d | 2023-05-23 | 2023-05-23 | C.70.10.02.2.11 SS | 42d | 0d |  |
| M.10.01.02.13 |  | Hito Planificado 3: Inicio de rellenos | milestone | 0d | 2023-06-14 | 2023-06-14 | M.10.01.02.12 SS+22d | 42d | 0d |  |
| M.10.01.02.14 |  | Hito Planificado 4: Culminación | milestone | 0d | 2023-12-02 | 2023-12-02 | C.90.03.11 FF, C.90.02.08.11 FF, C.90.02.06.11 FF, C.90.02.05.11 FF, T.20.12 FF, C.90.02.02.11 FF, C.90.02.03.11 FF | 0d |  |  |
|  | C | **CONSTRUCCIÓN** |  |  | 2023-05-18 | 2023-12-02 |  |  |  |  |
|  | 90 | **TRABAJOS PRELIMINARES** |  |  | 2023-05-18 | 2023-12-02 |  |  |  |  |
|  | 02 | **COSTOS DEL CONTRATISTA GENERAL** |  |  | 2023-05-18 | 2023-12-02 |  |  |  |  |
|  | 01 | **MOVILIZACIÓN** |  |  | 2023-10-12 | 2023-10-27 |  |  |  |  |
| C.90.02.01.12 |  | Movilización de equipos - Paisajismo |  | 16d | 2023-10-12 | 2023-10-27 | C.70.10.04.18 SS | 3d | 0d | as late as possible |

| ID | WBS | Activity | Type | Duration | Start | Finish | Predecessors | Total float | Free float | Constraint | Resources |
| --- | --- | --- | --- | --- | --- | --- | --- | --- | --- | --- | --- |
|  | 02 | **TRAZO Y REPLANTEO** |  |  | 2023-05-18 | 2023-12-02 |  |  |  |  |  |
| C.90.02.02.11 |  | Topografia y georreferenciación | level of effort | 199d | 2023-05-18 | 2023-12-02 | M.10.01.02.11 SS | 0d |  |  | HH [18108.1 h] |
| C.90.02.02.12 |  | Trazo y replanteo preliminar - Paisajismo | level of effort | 30d | 2023-10-28 | 2023-11-26 | C.70.03.01.11 SS | 3d | 0d |  | HH [78.67 h] |
|  | 03 | **SEGURIDAD INDUSTRIAL Y SALUD OCUPACIONAL** |  |  | 2023-05-18 | 2023-12-02 |  |  |  |  |  |
| C.90.02.03.11 |  | Seguridad y salud ocupacional | level of effort | 199d | 2023-05-18 | 2023-12-02 | M.10.01.02.11 SS | 0d |  |  |  |
|  | 04 | **INSTALACIONES PROVISIONALES PARA OBRA** |  |  | 2023-05-18 | 2023-11-15 |  |  |  |  |  |
| C.90.02.04.11 |  | Instalación de facilidades de obra |  | 21d | 2023-05-18 | 2023-06-07 | C.90.02.01.11 | 176d | 0d |  |  |
| C.90.02.04.12 |  | Colocación de Cartel de Identificación |  | 2d | 2023-06-08 | 2023-06-09 | C.90.02.04.11 | 176d |  |  | HH [31.55 h]; HM [0.38 h] |
| C.90.02.04.13 |  | Gastos de facilidades de obra | level of effort | 159d | 2023-06-10 | 2023-11-15 | C.90.02.04.12 | 0d |  |  |  |
|  | 05 | **GESTIÓN DE RESIDUOS** |  |  | 2023-05-18 | 2023-12-02 |  |  |  |  |  |
| C.90.02.05.12 |  | Acondicionamiento de DME | level of effort | 175d | 2023-05-18 | 2023-11-08 | M.10.01.02.11 SS | 0d |  |  | HH [10194.5 h]; HM [6934.33 h] |
| C.90.02.05.11 |  | Restauración de áreas de instalaciones provisionales |  | 24d | 2023-11-09 | 2023-12-02 | C.90.02.05.12 | 0d |  | as late as possible | HH [142.8 h]; HM [40.8 h] |
|  | 06 | **PLAN DE VIGILANCIA, PREVENCIÓN Y CONTROL COVID 19** |  |  | 2023-05-18 | 2023-12-02 |  |  |  |  |  |
| C.90.02.06.11 |  | Implementación del Plan para la vigilancia, prevención y control de COVID -19 | level of effort | 199d | 2023-05-18 | 2023-12-02 | M.10.01.02.11 SS | 0d |  |  |  |
|  | 07 | **TRANSPORTE** |  |  | 2023-05-23 | 2023-11-15 |  |  |  |  |  |
| C.90.02.07.15 |  | Transporte de material excedente < 1km | level of effort | 155d | 2023-05-23 | 2023-10-24 | M.10.01.02.12 SS | 0d |  |  | HH [10644.7 h]; HM [7499.14 h] |
| C.90.02.07.16 |  | Transporte de material excedente >1km | level of effort | 155d | 2023-05-23 | 2023-10-24 | M.10.01.02.12 SS | 0d |  |  | HH [86271.8 h]; HM [60778.2 h] |
| C.90.02.07.13 |  | Transporte de roca <1km | level of effort | 139d | 2023-06-28 | 2023-11-13 | C.70.10.01.17 SS | 0d |  |  | HH [3518.86 h]; HM [2479.03 h] |
| C.90.02.07.14 |  | Transporte de roca >1km | level of effort | 139d | 2023-06-28 | 2023-11-13 | C.70.10.01.17 SS | 0d |  |  | HH [54245.6 h]; HM [38215.8 h] |
| C.90.02.07.11 |  | Transporte de material granular < 1km | level of effort | 26d | 2023-10-21 | 2023-11-15 | C.70.11.01.13 SS | 0d |  |  | HH [833.06 h]; HM [586.89 h] |
| C.90.02.07.12 |  | Transporte de material granular >1km | level of effort | 26d | 2023-10-21 | 2023-11-15 | C.70.11.01.13 SS | 0d |  |  | HH [403.75 h]; HM [284.44 h] |
|  | 08 | **MANTENIMIENTO DE TRANSITO Y SEGURIDAD VIAL** |  |  | 2023-05-18 | 2023-12-02 |  |  |  |  |  |
| C.90.02.08.11 |  | Mantenimiento de tránsito y seguridad vial | level of effort | 199d | 2023-05-18 | 2023-12-02 | M.10.01.02.11 SS | 0d |  |  | HH [18108.1 h]; HM [4024.02 h] |
|  | 80 | **FACILIDADES DE OBRA** |  |  | 2023-05-22 | 2023-07-03 |  |  |  |  |  |
|  | 02 | **DEMOLICIONES** |  |  | 2023-05-24 | 2023-07-03 |  |  |  |  |  |
| C.80.02.16 |  | Demolición de sifon invertido |  | 1d | 2023-05-24 | 2023-05-24 | C.70.01.01.12 SS, C.70.01.01.16.1 SS | 144d |  |  | HH [11.36 h]; HM [10.13 h] |
| C.80.02.11 |  | Demolición de estructuras existentes - Punto de agua 1 |  | 1d | 2023-06-01 | 2023-06-01 | C.70.02.01.01.12 | 157d | 0d |  | HH [3.81 h]; HM [3.39 h] |
| C.80.02.12 |  | Demolición de estructuras existentes - Punto de agua 2 |  | 1d | 2023-06-02 | 2023-06-02 | C.80.02.11 | 157d | 0d |  | HH [3.81 h]; HM [3.39 h] |
| C.80.02.13 |  | Demolición de estructuras existentes - Punto de agua 3 |  | 2d | 2023-06-03 | 2023-06-04 | C.80.02.12 | 157d | 0d |  | HH [19.03 h]; HM [16.96 h] |
| C.80.02.15 |  | Demolición de canal 3 |  | 5d | 2023-06-23 | 2023-06-27 | C.70.01.01.12, C.70.01.01.16.1 | 109d |  |  | HH [847.95 h]; HM [755.71 h] |
| C.80.02.14 |  | Demolición de canal 1 |  | 8d | 2023-06-26 | 2023-07-03 | C.70.01.01.17, C.70.01.01.15 | 24d |  |  | HH [1450.36 h]; HM [1292.6 h] |

| ID | WBS | Activity | Duration | Start | Finish | Predecessors | Total float | Free float | Resources | SECTOR |
| --- | --- | --- | --- | --- | --- | --- | --- | --- | --- | --- |
|  | 04 | **OBRAS DE DESVIO TEMPORAL** |  | 2023-05-22 | 2023-06-26 |  |  |  |  |  |
| C.80.02.19 |  | Conformación de desvió en cauce de río Dique A3-D-02 - Sector 2 | 9d | 2023-05-22 | 2023-05-30 | C.70.01.01.14 SS | 19d | 0d | HH [138.1 h]; HM [65.93 h] | S2 |
| C.80.02.17 |  | Conformación de desvió en cauce de río Dique A3-D-01 | 5d | 2023-05-25 | 2023-05-29 | C.70.01.01.12 SS+1d | 42d | 0d | HH [72.46 h]; HM [34.59 h] | S4 |
| C.80.02.20 |  | Conformación de desvió en cauce de río Dique A3-D-02 - Sector 3 | 4d | 2023-06-03 | 2023-06-06 | C.70.01.01.15 SS+12d | 8d | 0d | HH [162.57 h]; HM [77.61 h] | S1 |
| C.80.02.24 |  | Conformación de desvió en cauce de río Dique A3-I-03 - Sector 2 | 6d | 2023-06-03 | 2023-06-08 | C.70.01.01.19 SS+12d | 0d |  | HH [162.57 h]; HM [77.61 h] | S1 |
| C.80.02.18 |  | Conformación de desvió en cauce de río Dique A3-D-02 - Sector 1 | 5d | 2023-06-12 | 2023-06-16 | C.70.01.01.13 | 7d | 0d | HH [69.91 h]; HM [33.37 h] | S3 |
| C.80.02.23.1 |  | Conformación de desvió en cauce de río Dique A3-I-03 - Sector 1 - Tramo 1 | 5d | 2023-06-22 | 2023-06-26 | C.70.01.01.18.1 | 2d | 0d | HH [138.1 h]; HM [65.93 h] | S2 |
| C.80.02.21.1 |  | Conformación de desvió en cauce de río Dique A3-I-01 - Tramo 1 | 3d | 2023-06-23 | 2023-06-25 | C.70.01.01.16.1 | 21d | 0d | HH [72.46 h]; HM [34.59 h] | S4 |
| C.80.02.22 |  | Conformación de desvió en cauce de río Dique A3-I-02 | 2d | 2023-06-25 | 2023-06-26 | C.70.01.01.17 | 0d |  | HH [69.91 h]; HM [33.37 h] | S3 |
|  | 70 | **OBRAS EXTERIORES** |  | 2023-05-18 | 2023-11-26 |  |  |  |  |  |
|  | 01 | **PREPARACION DEL SITIO** |  | 2023-05-18 | 2023-07-19 |  |  |  |  |  |
|  | 01 | **LIMPIEZA** |  | 2023-05-18 | 2023-06-25 |  |  |  |  |  |
| C.70.01.01.11 |  | Roce y limpieza de vías | 5d | 2023-05-18 | 2023-05-22 | M.10.01.02.11 SS | 158d | 1d | HH [419.1 h]; HM [190.52 h] |  |
| C.70.01.01.14 |  | Desbroce y limpieza Dique A3-D-02 - Sector 2 | 33d | 2023-05-22 | 2023-06-23 | C.70.02.01.01.11 | 19d | 0d | HH [3915.65 h]; HM [1213.24 h] | S2 |
| C.70.01.01.15 |  | Desbroce y limpieza Dique A3-D-02 - Sector 3 | 35d | 2023-05-22 | 2023-06-25 | C.70.02.01.01.11 | 8d | 0d | HH [4268.54 h]; HM [1322.58 h] | S1 |
| C.70.01.01.18.1 |  | Desbroce y limpieza Dique A3-I-03 - Sector 1 - Tramo 1 | 31d | 2023-05-22 | 2023-06-21 | C.70.02.01.01.11 | 2d | 0d | HH [3277.66 h]; HM [1015.57 h] | S2 |
| C.70.01.01.19 |  | Desbroce y limpieza Dique A3-I-03 - Sector 2 | 34d | 2023-05-22 | 2023-06-24 | C.70.02.01.01.11 | 0d |  | HH [3677.38 h]; HM [1139.42 h] | S1 |
| C.70.01.01.12 |  | Desbroce y limpieza Dique A3-D-01 | 16d | 2023-05-24 | 2023-06-08 | C.70.02.01.01.14 | 42d | 0d | HH [1863.01 h]; HM [577.24 h] | S4 |
| C.70.01.01.13 |  | Desbroce y limpieza Dique A3-D-02 - Sector 1 | 19d | 2023-05-24 | 2023-06-11 | C.70.02.01.01.14 | 7d | 0d | HH [2005.58 h]; HM [621.42 h] | S3 |
| C.70.01.01.16.1 |  | Desbroce y limpieza Dique A3-I-01 - Tramo 1 | 30d | 2023-05-24 | 2023-06-22 | C.70.02.01.01.14 | 21d | 0d | HH [6495.4 h]; HM [2012.57 h] | S4 |
| C.70.01.01.17 |  | Desbroce y limpieza Dique A3-I-02 | 32d | 2023-05-24 | 2023-06-24 | C.70.02.01.01.14 | 0d |  | HH [3891.92 h]; HM [1205.89 h] | S3 |
|  | 02 | **DESCOLMATACIÓN** |  | 2023-05-22 | 2023-07-19 |  |  |  |  |  |
| C.70.01.02.13 |  | Descolmatación Dique A3-D-02 - Sector 2 | 23d | 2023-05-22 | 2023-06-13 | C.80.02.19 SS | 19d | 0d | HH [532.41 h]; HM [343.59 h] | S2 |
| C.70.01.02.21 |  | Relleno no estructural Dique A3-D-02 - Sector 2 | 9d | 2023-05-22 | 2023-05-30 | C.70.01.02.13 SS | 19d | 0d | HH [138.1 h]; HM [65.93 h] | S2 |
| C.70.01.02.11 |  | Descolmatación Dique A3-D-01 | 11d | 2023-05-26 | 2023-06-05 | C.80.02.17 SS+1d | 42d | 0d | HH [253.31 h]; HM [163.48 h] | S4 |
| C.70.01.02.19 |  | Relleno no estructural Dique A3-D-01 | 5d | 2023-05-27 | 2023-05-31 | C.70.01.02.11 SS+1d | 42d | 0d | HH [75.72 h]; HM [36.15 h] | S4 |
| C.70.01.02.14 |  | Descolmatación Dique A3-D-02 - Sector 3 | 10d | 2023-06-07 | 2023-06-16 | C.80.02.20 | 8d | 0d | HH [580.4 h]; HM [374.56 h] | S1 |
| C.70.01.02.18 |  | Descolmatación Dique A3-I-03 - Sector 2 | 12d | 2023-06-09 | 2023-06-20 | C.80.02.24 | 0d |  | HH [500.01 h]; HM [322.68 h] | S1 |
| C.70.01.02.12 |  | Descolmatación Dique A3-D-02 - Sector 1 | 13d | 2023-06-17 | 2023-06-29 | C.80.02.18 | 7d | 0d | HH [272.7 h]; HM [175.99 h] | S3 |
| C.70.01.02.22 |  | Relleno no estructural Dique A3-D-02 - Sector 3 | 4d | 2023-06-17 | 2023-06-20 | C.70.01.02.14 | 8d | 0d | HH [162.57 h]; HM [77.61 h] | S1 |
| C.70.01.02.26 |  | Relleno no estructural Dique A3-I-03 - Sector 2 | 6d | 2023-06-21 | 2023-06-26 | C.70.01.02.18 | 0d |  | HH [162.57 h]; HM [77.61 h] | S1 |
| C.70.01.02.15.1 |  | Descolmatación Dique A3-I-01 - Tramo 1 | 21d | 2023-06-26 | 2023-07-16 | C.80.02.21.1 | 21d | 0d | HH [883.18 h]; HM [569.96 h] | S4 |
| C.70.01.02.16 |  | Descolmatación Dique A3-I-02 | 8d | 2023-06-27 | 2023-07-04 | C.80.02.22 | 0d |  | HH [529.19 h]; HM [341.51 h] | S3 |
| C.70.01.02.17.1 |  | Descolmatación Dique A3-I-03 - Sector 1 - Tramo 1 | 11d | 2023-06-27 | 2023-07-07 | C.80.02.23.1 | 2d | 0d | HH [445.67 h]; HM [287.61 h] | S2 |
| C.70.01.02.20 |  | Relleno no estructural Dique A3-D-02 - Sector 1 | 5d | 2023-06-30 | 2023-07-04 | C.70.01.02.12 | 7d | 0d | HH [69.91 h]; HM [33.37 h] | S3 |
| C.70.01.02.24 |  | Relleno no estructural Dique A3-I-02 | 2d | 2023-07-05 | 2023-07-06 | C.70.01.02.16 | 0d |  | HH [69.91 h]; HM [33.37 h] | S3 |
| C.70.01.02.25.1 |  | Relleno no estructural Dique A3-I-03 - Sector 1 - Tramo 1 | 5d | 2023-07-08 | 2023-07-12 | C.70.01.02.17.1 | 2d | 0d | HH [138.1 h]; HM [65.93 h] | S2 |
| C.70.01.02.23.1 |  | Relleno no estructural Dique A3-I-01- Tramo 1 | 3d | 2023-07-17 | 2023-07-19 | C.70.01.02.15.1 | 21d | 0d | HH [72.46 h]; HM [34.59 h] | S4 |

| ID | WBS | Activity | Type | Duration | Start | Finish | Predecessors | Total float | Free float | Resources | SECTOR |
| --- | --- | --- | --- | --- | --- | --- | --- | --- | --- | --- | --- |
|  | 02 | **CAMINOS PROVISIONALES** |  |  | 2023-05-18 | 2023-06-11 |  |  |  |  |  |
|  | 01 | **MEJORAMIENTO DE VIAS** |  |  | 2023-05-18 | 2023-06-11 |  |  |  |  |  |
|  | 01 | **MEJORAMIENTO DE VIAS EXISTENTES** |  |  | 2023-05-18 | 2023-05-31 |  |  |  |  |  |
| C.70.02.01.01.11 |  | Mejoramiento de vías - Vía Acceso AN-879 |  | 4d | 2023-05-18 | 2023-05-21 | M.10.01.02.11 SS | 0d |  | HH [168.34 h]; HM [49.51 h] | S5 |
| C.70.02.01.01.14 |  | Mejoramiento de vías - EMPALME CHACHAPOYAS |  | 2d | 2023-05-22 | 2023-05-23 | C.70.02.01.01.11 | 0d |  | HH [78.03 h]; HM [22.95 h] | S5 |
| C.70.02.01.01.13 |  | Mejoramiento de vías - EMPALME CANAL - DME-3A |  | 4d | 2023-05-24 | 2023-05-27 | C.70.02.01.01.14, C.70.01.01.11 | 157d | 0d | HH [216.75 h]; HM [63.75 h] | S5 |
| C.70.02.01.01.12 |  | Mejoramiento de vías - FA-07 --AN-879 |  | 4d | 2023-05-28 | 2023-05-31 | C.70.02.01.01.13 | 157d | 0d | HH [203.03 h]; HM [59.72 h] | S5 |
|  | 02 | **REPOSICIÓN DE ESTRUCTURAS EXISTENTES** |  |  | 2023-06-02 | 2023-06-07 |  |  |  |  |  |
|  | 01 | **PUNTO DE AGUA 1** |  |  | 2023-06-02 | 2023-06-04 |  |  |  |  |  |
| C.70.02.01.02.01.11 |  | Suministro de paneles de C°A° |  | 3d | 2023-06-02 | 2023-06-04 | C.80.02.11 | 164d |  | HH [98.14 h]; HM [35.36 h] |  |
|  | 02 | **PUNTO DE AGUA 2** |  |  | 2023-06-03 | 2023-06-03 |  |  |  |  |  |
| C.70.02.01.02.02.11 |  | Suministro de paneles de C°A° |  | 1d | 2023-06-03 | 2023-06-03 | C.80.02.12 | 165d |  | HH [99.61 h]; HM [36.33 h] |  |
|  | 03 | **PUNTO DE AGUA 3** |  |  | 2023-06-05 | 2023-06-07 |  |  |  |  |  |
| C.70.02.01.02.03.11 |  | Reposición de pase agua tubo HDPE 36" |  | 3d | 2023-06-05 | 2023-06-07 | C.80.02.13 | 157d | 0d | HH [10.55 h]; HM [2.95 h] |  |
| C.70.02.01.02.03.12 |  | Reposición de pase agua tubo HDPE 18" |  | 2d | 2023-06-05 | 2023-06-06 | C.80.02.13 | 158d | 1d | HH [4.98 h]; HM [1.32 h] |  |
|  | 03 | **CABEZAL DE ENTRADA Y SALIDA** |  |  | 2023-06-08 | 2023-06-11 |  |  |  |  |  |
| C.70.02.01.03.11 |  | Encofrado recto cabeza de entrada |  | 1d | 2023-06-08 | 2023-06-08 | C.70.02.01.02.03.11, C.70.02.01.02.03.12 | 157d | 0d | HH [24.32 h]; HM [9.35 h] |  |
| C.70.02.01.03.12 |  | Concreto cabezal de entrada |  | 1d | 2023-06-09 | 2023-06-09 | C.70.02.01.03.11 | 157d | 0d | HH [35.51 h]; HM [5.67 h] |  |
| C.70.02.01.03.14 |  | Encofrado recto cabeza de salida |  | 1d | 2023-06-09 | 2023-06-09 | C.70.02.01.03.11 | 157d | 0d | HH [12.38 h]; HM [4.76 h] |  |
| C.70.02.01.03.13 |  | Desconfrado de cabezal de entrada |  | 1d | 2023-06-10 | 2023-06-10 | C.70.02.01.03.12 | 157d | 0d | HH [24.32 h]; HM [9.35 h] |  |
| C.70.02.01.03.15 |  | Concreto cabezal de salida |  | 1d | 2023-06-10 | 2023-06-10 | C.70.02.01.03.12, C.70.02.01.03.14 | 157d | 0d | HH [16.25 h]; HM [2.6 h] |  |
| C.70.02.01.03.16 |  | Desconfrado de cabezal de salida |  | 1d | 2023-06-11 | 2023-06-11 | C.70.02.01.03.13, C.70.02.01.03.15 | 157d |  | HH [12.38 h]; HM [4.76 h] |  |
|  | 03 | **PLANTACIÓN Y PAISAJISMO** |  |  | 2023-10-28 | 2023-11-12 |  |  |  |  |  |
|  | 01 | **MOVIMIENTO DE TIERRAS** |  |  | 2023-10-28 | 2023-10-31 |  |  |  |  |  |
| C.70.03.01.11 |  | Excavación manual para instalación de bordillos |  | 3d | 2023-10-28 | 2023-10-30 | C.90.02.01.12, C.70.10.04.15 | 3d | 0d | HH [20.79 h] |  |
| C.70.03.01.13 |  | Eliminación material excedente | level of effort | 4d | 2023-10-28 | 2023-10-31 | C.70.03.01.11 SS | 3d | 0d | HH [3.53 h]; HM [3.02 h] |  |
| C.70.03.01.12 |  | Excavación para mejoramiento con tierra vegetal |  | 1d | 2023-10-31 | 2023-10-31 | C.70.03.01.11, C.70.03.01.13 FF | 3d | 0d | HH [1.6 h]; HM [0.76 h] |  |

| ID | WBS | Activity | Type | Duration | Start | Finish | Predecessors | Total float | Free float | Resources | SECTOR |
| --- | --- | --- | --- | --- | --- | --- | --- | --- | --- | --- | --- |
|  | 02 | **PAVIMENTOS, RECUBRIMIENTOS Y BORDILLOS** |  |  | 2023-11-01 | 2023-11-11 |  |  |  |  |  |
| C.70.03.02.11 |  | Piso de gravilla |  | 2d | 2023-11-01 | 2023-11-02 | C.70.03.01.12 | 3d | 0d | HH [44.53 h]; HM [10.41 h] |  |
| C.70.03.02.13 |  | Bordillos de piedra de lugar |  | 5d | 2023-11-03 | 2023-11-07 | C.70.03.02.11 | 3d | 0d | HH [167.13 h]; HM [1.82 h] |  |
| C.70.03.02.12 |  | Recubrimiento de piedra de lugar |  | 4d | 2023-11-08 | 2023-11-11 | C.70.03.02.13 | 3d | 0d | HH [63.19 h] |  |
|  | 04 | **INSTALACIÓN DE ALCORQUES** |  |  | 2023-11-12 | 2023-11-12 |  |  |  |  |  |
| C.70.03.03.11 |  | Instalación de alcorques de piedra |  | 0d | 2023-11-12 | 2023-11-12 | C.70.03.02.12 | 3d | 0d |  |  |
|  | 05 | **MOBILIARIO Y EQUIPAMIENTO URBANO** |  |  | 2023-11-12 | 2023-11-26 |  |  |  |  |  |
|  | 01 | **MOBILIARIOS, BARANDAS Y ESCALERAS** |  |  | 2023-11-12 | 2023-11-26 |  |  |  |  |  |
| C.70.05.01.11 |  | Escalera de concreto sobre enrocado |  | 2d | 2023-11-12 | 2023-11-13 | C.70.03.03.11 | 3d | 0d | HH [329.05 h]; HM [191.73 h] |  |
| C.70.05.01.12 |  | Baranda de madera eucalipto con soga |  | 3d | 2023-11-14 | 2023-11-16 | C.70.05.01.11 | 3d | 0d | HH [99.9 h]; HM [48 h] |  |
| C.70.05.01.13 |  | Tachos de basura |  | 2d | 2023-11-17 | 2023-11-18 | C.70.05.01.12 | 3d | 0d | HH [46.81 h]; HM [2.62 h] |  |
| C.70.05.01.14 |  | Bancas de concreto |  | 2d | 2023-11-19 | 2023-11-20 | C.70.05.01.13 | 3d | 0d | HH [71.55 h]; HM [5.31 h] |  |
| C.70.05.01.15 |  | Postes de iluminación |  | 2d | 2023-11-21 | 2023-11-22 | C.70.05.01.14 | 3d | 0d | HH [43.47 h]; HM [2.24 h] |  |
| C.70.05.01.16 |  | Señalética informativa |  | 2d | 2023-11-23 | 2023-11-24 | C.70.05.01.15 | 3d | 0d | HH [43.47 h]; HM [2.24 h] |  |
| C.70.05.01.17 |  | Bolardos de Piedra |  | 2d | 2023-11-25 | 2023-11-26 | C.70.05.01.16, C.90.02.02.12 FF | 3d |  | HH [20 h]; HM [5 h] |  |
|  | 10 | **CUERPOS DE TERRAPLEN** |  |  | 2023-05-23 | 2023-11-15 |  |  |  |  |  |
|  | 01 | **DIQUE A3-D-01** |  |  | 2023-05-28 | 2023-10-04 |  |  |  |  |  |
| C.70.10.01.11 |  | Excavación en terreno natural con equipo |  | 8d | 2023-05-28 | 2023-06-04 | C.70.01.02.19 SS+1d | 42d | 0d | EXCAVACIONES [6167.17]; HH [319.46 h]; HM [205.98 h] | S4 |
| C.70.10.01.13 |  | Perfilado y compatación en zona de corte |  | 9d | 2023-06-05 | 2023-06-13 | C.70.10.01.11 | 42d | 0d | HH [635.71 h]; HM [288.76 h] | S4 |
| C.70.10.01.19 |  | Preparación de fundación cuerpo de dique | level of effort | 16d | 2023-06-05 | 2023-06-20 | C.70.10.01.13 SS | 42d | 0d | HH [72.28 h]; HM [36.27 h] | S4 |
| C.70.10.01.14 |  | Conformación de cuerpo de dique |  | 7d | 2023-06-14 | 2023-06-20 | C.70.10.01.13, C.70.10.01.19 FF, M.10.01.02.13 SS | 42d | 0d | RELLENOS [1639.2]; HH [338 h]; HM [216.37 h] | S4 |
| C.70.10.01.12 |  | Excavación de uña con equipo |  | 7d | 2023-06-21 | 2023-06-27 | C.70.10.01.14 | 42d | 0d | EXCAVACIONES [2325.01]; HH [144.15 h]; HM [139.5 h] | S4 |
| C.70.10.01.16 |  | Instalación de geotextil no tejido |  | 36d | 2023-06-28 | 2023-08-02 | C.70.10.01.12 | 42d | 0d | HH [417.09 h] | S4 |
| C.70.10.01.17 |  | Colocación y acomodo de roca en uña |  | 29d | 2023-06-28 | 2023-07-26 | C.70.10.01.16 SS | 42d | 0d | ENROCADOS [2325.01]; HH [1026.73 h]; HM [426.18 h] | S4 |
| C.70.10.01.18 |  | Colocación y acomodo de roca en talud |  | 65d | 2023-07-27 | 2023-09-29 | C.70.10.01.17, C.70.10.01.16 FF | 42d | 0d | ENROCADOS [3493.37]; HH [2139.69 h]; HM [786.01 h] | S4 |
| C.70.10.01.15 |  | Conformación de corona de dique |  | 5d | 2023-09-30 | 2023-10-04 | C.70.10.01.18, C.70.10.01.16 | 42d |  | HH [327.28 h]; HM [165.34 h] | S4 |

| ID | WBS | Activity | Type | Duration | Start | Finish | Predecessors | Total float | Free float | Resources | SECTOR |
| --- | --- | --- | --- | --- | --- | --- | --- | --- | --- | --- | --- |
|  | 02 | **DIQUE A3-D-02** |  |  | 2023-05-23 | 2023-11-08 |  |  |  |  |  |
|  | 1 | **SECTOR 1** |  |  | 2023-07-05 | 2023-11-08 |  |  |  |  |  |
| C.70.10.02.1.11 |  | Excavación en terreno natural con equipo |  | 35d | 2023-07-05 | 2023-08-08 | C.70.01.02.20 | 7d | 0d | EXCAVACIONES [15433.6]; HH [799.46 h]; HM [515.48 h] | S3 |
| C.70.10.02.1.13 |  | Perfilado y compatación en zona de corte |  | 15d | 2023-08-09 | 2023-08-23 | C.70.10.02.1.11 | 7d | 0d | HH [558.22 h]; HM [253.56 h] | S3 |
| C.70.10.02.1.19 |  | Preparación de fundación cuerpo de dique | level of effort | 21d | 2023-08-09 | 2023-08-29 | C.70.10.02.1.13 SS | 7d | 0d | HH [57.83 h]; HM [29.02 h] | S3 |
| C.70.10.02.1.14 |  | Conformación de cuerpo de dique |  | 6d | 2023-08-24 | 2023-08-29 | C.70.10.02.1.13, C.70.10.02.1.19 FF | 7d | 0d | RELLENOS [1487.3]; HH [306.68 h]; HM [196.32 h] | S3 |
| C.70.10.02.1.12 |  | Excavación de uña con equipo |  | 10d | 2023-08-30 | 2023-09-08 | C.70.10.02.1.14 | 7d | 0d | EXCAVACIONES [3144.9]; HH [194.98 h]; HM [188.69 h] | S3 |
| C.70.10.02.1.16 |  | Instalación de geotextil no tejido |  | 32d | 2023-09-09 | 2023-10-10 | C.70.10.02.1.12 | 7d | 0d | HH [375.63 h] | S3 |
| C.70.10.02.1.17 |  | Colocación y acomodo de roca en uña |  | 20d | 2023-09-09 | 2023-09-28 | C.70.10.02.1.16 SS | 7d | 0d | ENROCADOS [3144.9]; HH [1388.79 h]; HM [576.46 h] | S3 |
| C.70.10.02.1.18 |  | Colocación y acomodo de roca en talud |  | 36d | 2023-09-29 | 2023-11-03 | C.70.10.02.1.17, C.70.10.02.1.16 FF | 7d | 0d | ENROCADOS [3901.4]; HH [2389.61 h]; HM [877.82 h] | S3 |
| C.70.10.02.1.15 |  | Conformación de corona de dique |  | 5d | 2023-11-04 | 2023-11-08 | C.70.10.02.1.18, C.70.10.02.1.16 | 7d |  | HH [315.28 h]; HM [159.28 h] | S3 |
|  | 2 | **SECTOR 2** |  |  | 2023-05-23 | 2023-10-17 |  |  |  |  |  |
| C.70.10.02.2.11 |  | Excavación en terreno natural con equipo |  | 21d | 2023-05-23 | 2023-06-12 | C.70.01.02.21 SS+1d | 19d | 0d | EXCAVACIONES [17674.7]; HH [915.55 h]; HM [590.34 h] | S2 |
| C.70.10.02.2.13 |  | Perfilado y compatación en zona de corte |  | 23d | 2023-06-13 | 2023-07-05 | C.70.10.02.2.11 | 19d | 0d | HH [1748.96 h]; HM [794.42 h] | S2 |
| C.70.10.02.2.19 |  | Preparación de fundación cuerpo de dique | level of effort | 30d | 2023-06-13 | 2023-07-12 | C.70.10.02.2.13 SS | 19d | 0d | HH [112.9 h]; HM [56.65 h] | S2 |
| C.70.10.02.2.14 |  | Conformación de cuerpo de dique |  | 7d | 2023-07-06 | 2023-07-12 | C.70.10.02.2.13, C.70.10.02.2.19 FF | 19d | 0d | RELLENOS [3362.3]; HH [693.31 h]; HM [443.82 h] | S2 |
| C.70.10.02.2.12 |  | Excavación de uña con equipo |  | 10d | 2023-07-13 | 2023-07-22 | C.70.10.02.2.14 | 19d | 0d | EXCAVACIONES [6494.4]; HH [402.65 h]; HM [389.66 h] | S2 |
| C.70.10.02.2.16 |  | Instalación de geotextil no tejido |  | 66d | 2023-07-23 | 2023-09-26 | C.70.10.02.2.12 | 19d | 0d | HH [780.31 h] | S2 |
| C.70.10.02.2.17 |  | Colocación y acomodo de roca en uña |  | 27d | 2023-07-23 | 2023-08-18 | C.70.10.02.2.16 SS | 19d | 0d | ENROCADOS [6494.4]; HH [2867.93 h]; HM [1190.42 h] | S2 |
| C.70.10.02.2.18 |  | Colocación y acomodo de roca en talud |  | 51d | 2023-08-19 | 2023-10-08 | C.70.10.02.2.17, C.70.10.02.2.16 FF | 19d | 0d | ENROCADOS [8322.3]; HH [5097.41 h]; HM [1872.52 h] | S2 |
| C.70.10.02.2.15 |  | Conformación de corona de dique |  | 9d | 2023-10-09 | 2023-10-17 | C.70.10.02.2.18, C.70.10.02.2.16 | 19d | 0d | HH [640.97 h]; HM [323.82 h] | S2 |
|  | 3 | **SECTOR 3** |  |  | 2023-06-21 | 2023-11-07 |  |  |  |  |  |
| C.70.10.02.3.10 |  | Excavación en terreno natural con equipo |  | 16d | 2023-06-21 | 2023-07-06 | C.70.01.02.22 | 8d | 0d | EXCAVACIONES [20177.7]; HH [1045.2 h]; HM [673.93 h] | S1 |
| C.70.10.02.3.12 |  | Perfilado y compatación en zona de corte |  | 22d | 2023-07-07 | 2023-07-28 | C.70.10.02.3.10 | 8d | 0d | HH [1651.38 h]; HM [750.1 h] | S1 |
| C.70.10.02.3.18 |  | Preparación de fundación cuerpo de dique | level of effort | 26d | 2023-07-07 | 2023-08-01 | C.70.10.02.3.12 SS | 8d | 0d | HH [123.07 h]; HM [61.75 h] | S1 |
| C.70.10.02.3.13 |  | Conformación de cuerpo de dique |  | 4d | 2023-07-29 | 2023-08-01 | C.70.10.02.3.12, C.70.10.02.3.18 FF | 8d | 0d | RELLENOS [2091.3]; HH [431.23 h]; HM [276.05 h] | S1 |
| C.70.10.02.3.11 |  | Excavación de uña con equipo |  | 11d | 2023-08-02 | 2023-08-12 | C.70.10.02.3.13 | 8d | 0d | EXCAVACIONES [7079.69]; HH [438.94 h]; HM [424.78 h] | S1 |
| C.70.10.02.3.15 |  | Instalación de geotextil no tejido |  | 62d | 2023-08-13 | 2023-10-13 | C.70.10.02.3.11 | 8d | 0d | HH [732.3 h] | S1 |
| C.70.10.02.3.16 |  | Colocación y acomodo de roca en uña |  | 29d | 2023-08-13 | 2023-09-10 | C.70.10.02.3.15 SS | 8d | 0d | ENROCADOS [7079.69]; HH [3126.39 h]; HM [1297.71 h] | S1 |
| C.70.10.02.3.17 |  | Colocación y acomodo de roca en talud |  | 48d | 2023-09-11 | 2023-10-28 | C.70.10.02.3.16, C.70.10.02.3.15 FF | 8d | 0d | ENROCADOS [7799.43]; HH [4777.15 h]; HM [1754.87 h] | S1 |
| C.70.10.02.3.14 |  | Conformación de corona de dique |  | 10d | 2023-10-29 | 2023-11-07 | C.70.10.02.3.17, C.70.10.02.3.15 | 8d |  | HH [697.11 h]; HM [352.17 h] | S1 |

| ID | WBS | Activity | Type | Duration | Start | Finish | Predecessors | Total float | Free float | Constraint | Resources | SECTOR |
| --- | --- | --- | --- | --- | --- | --- | --- | --- | --- | --- | --- | --- |
|  | 03 | **DIQUE A3-I-01** |  |  | 2023-07-20 | 2023-11-15 |  |  |  |  |  |  |
|  | 1 | **Tramo 1 (PK 20+960 - 21+300)** |  |  | 2023-09-30 | 2023-11-15 |  |  |  |  |  |  |
| C.70.10.03.20 |  | Excavación en terreno natural con equipo |  | 8d | 2023-09-30 | 2023-10-07 | C.70.10.03.11, C.70.10.05.1.21 | 0d |  | as late as possible | EXCAVACIONES [3244.4]; HH [168.06 h]; HM [108.36 h] |  |
| C.70.10.03.22 |  | Perfilado y compatación en zona de corte |  | 5d | 2023-10-08 | 2023-10-12 | C.70.10.03.20, C.70.10.03.13 | 0d |  | as late as possible | HH [182.07 h]; HM [82.7 h] |  |
| C.70.10.03.28 |  | Preparación de fundación cuerpo de dique | level of effort | 14d | 2023-10-08 | 2023-10-21 | C.70.10.03.22 SS | 0d |  |  | HH [37.31 h]; HM [18.72 h] |  |
| C.70.10.03.23 |  | Conformación de cuerpo de dique |  | 9d | 2023-10-13 | 2023-10-21 | C.70.10.03.22, C.70.10.03.28 FF, C.70.10.03.14 | 0d |  | as late as possible | RELLENOS [306.57]; HH [2322.5 h]; HM [478.9 h] |  |
| C.70.10.03.21 |  | Excavación de uña con equipo |  | 3d | 2023-10-22 | 2023-10-24 | C.70.10.03.23, C.70.10.03.12, C.90.02.07.15 FF, C.90.02.07.16 FF | 0d |  | as late as possible | EXCAVACIONES [880]; HH [54.56 h]; HM [52.8 h] |  |
| C.70.10.03.25 |  | Instlación de geotextil no tejido |  | 15d | 2023-10-25 | 2023-11-08 | C.70.10.03.21, C.70.10.03.16, C.70.10.05.1.25 | 0d |  | as late as possible | HH [177.17 h] |  |
| C.70.10.03.26 |  | Colocación y acomodo de roca en uña |  | 6d | 2023-10-25 | 2023-10-30 | C.70.10.03.25 SS, C.70.10.03.17, C.70.10.05.1.27 | 0d |  | as late as possible | ENROCADOS [880]; HH [388.61 h]; HM [161.3 h] |  |
| C.70.10.03.27 |  | Colocaicón y acomodo de roca en talud |  | 14d | 2023-10-31 | 2023-11-13 | C.70.10.03.26, C.70.10.03.25 FF, C.70.10.03.18, C.90.02.07.13 FF, C.90.02.07.14 FF | 0d |  | as late as possible | ENROCADOS [1525.5]; HH [934.37 h]; HM [343.24 h] |  |
| C.70.10.03.24 |  | Conformación de corona de dique |  | 2d | 2023-11-14 | 2023-11-15 | C.70.10.03.27, C.70.10.03.25, C.70.10.03.15, C.70.10.05.1.24, C.90.02.07.11 FF, C.90.02.07.12 FF | 0d |  | as late as possible | HH [123.99 h]; HM [62.64 h] |  |
|  | 2 | **Tramo 2 (PK 21+300 - 21+805)** |  |  | 2023-07-20 | 2023-09-28 |  |  |  |  |  |  |
| C.70.10.03.11 |  | Excavación en terreno natural con equipo |  | 24d | 2023-07-20 | 2023-08-12 | C.70.01.02.23.1 | 21d | 0d |  | EXCAVACIONES [10520]; HH [544.94 h]; HM [351.37 h] | S4 |
| C.70.10.03.13 |  | Perfilado y compatación en zona de corte |  | 10d | 2023-08-13 | 2023-08-22 | C.70.10.03.11 | 35d | 0d |  | HH [374.6 h]; HM [170.15 h] | S4 |
| C.70.10.03.19 |  | Preparación de fundación cuerpo de dique | level of effort | 12d | 2023-08-13 | 2023-08-24 | C.70.10.03.13 SS | 35d | 0d |  | HH [59.17 h]; HM [29.69 h] | S4 |
| C.70.10.03.14 |  | Conformación de cuerpo de dique |  | 2d | 2023-08-23 | 2023-08-24 | C.70.10.03.13, C.70.10.03.19 FF | 35d | 0d |  | RELLENOS [470.6]; HH [97.04 h]; HM [62.12 h] | S4 |
| C.70.10.03.12 |  | Excavación de uña con equipo |  | 5d | 2023-08-25 | 2023-08-29 | C.70.10.03.14 | 35d | 0d |  | EXCAVACIONES [1395.54]; HH [86.52 h]; HM [83.73 h] | S4 |
| C.70.10.03.16 |  | Instalación de geotextil no tejido |  | 20d | 2023-08-30 | 2023-09-18 | C.70.10.03.12 | 35d | 0d |  | HH [231.77 h] | S4 |
| C.70.10.03.17 |  | Colocación y acomodo de roca en uña |  | 9d | 2023-08-30 | 2023-09-07 | C.70.10.03.16 SS | 35d | 0d |  | ENROCADOS [1395.54]; HH [616.27 h]; HM [255.8 h] | S4 |
| C.70.10.03.18 |  | Colocación y acomodo de roca en talud |  | 18d | 2023-09-08 | 2023-09-25 | C.70.10.03.17, C.70.10.03.16 FF | 35d | 0d |  | ENROCADOS [1900.76]; HH [1164.22 h]; HM [427.67 h] | S4 |
| C.70.10.03.15 |  | Conformación de corona de dique |  | 3d | 2023-09-26 | 2023-09-28 | C.70.10.03.18, C.70.10.03.16 | 46d |  |  | HH [196.64 h]; HM [99.34 h] | S4 |
|  | 04 | **DIQUE A3-I-02** |  |  | 2023-07-07 | 2023-10-27 |  |  |  |  |  |  |
| C.70.10.04.11 |  | Excavación en terreno natural con equipo |  | 21d | 2023-07-07 | 2023-07-27 | C.70.01.02.24 | 0d |  |  | EXCAVACIONES [18781.3]; HH [972.87 h]; HM [627.3 h] | S3 |
| C.70.10.04.13 |  | Perfilado y compatación en zona de corte |  | 18d | 2023-07-28 | 2023-08-14 | C.70.10.04.11 | 3d | 0d |  | HH [693.19 h]; HM [314.87 h] | S3 |
| C.70.10.04.19 |  | Preparación de fundación cuerpo de dique | level of effort | 21d | 2023-07-28 | 2023-08-17 | C.70.10.04.13 SS | 3d | 0d |  | HH [40.06 h]; HM [20.1 h] | S3 |
| C.70.10.04.14 |  | Conformación de cuerpo de dique |  | 3d | 2023-08-15 | 2023-08-17 | C.70.10.04.13, C.70.10.04.19 FF | 3d | 0d |  | HH [119.3 h]; HM [76.37 h] | S3 |
| C.70.10.04.12 |  | Excavación de uña con equipo |  | 10d | 2023-08-18 | 2023-08-27 | C.70.10.04.14 | 3d | 0d |  | EXCAVACIONES [3101.07]; HH [192.27 h]; HM [186.06 h] | S3 |
| C.70.10.04.16 |  | Instalación de geotextil no tejido |  | 31d | 2023-08-28 | 2023-09-27 | C.70.10.04.12 | 3d | 0d |  | HH [368.28 h] | S3 |
| C.70.10.04.17 |  | Colocación y acomodo de roca en uña |  | 19d | 2023-08-28 | 2023-09-15 | C.70.10.04.16 SS | 3d | 0d |  | ENROCADOS [3101.07]; HH [1369.43 h]; HM [568.43 h] | S3 |
| C.70.10.04.18 |  | Colocación y acomodo de roca en talud |  | 36d | 2023-09-16 | 2023-10-21 | C.70.10.04.17, C.70.10.04.16 FF | 3d | 0d |  | ENROCADOS [3837.2]; HH [2350.29 h]; HM [863.37 h] | S3 |
| C.70.10.04.15 |  | Conformación de corona de dique |  | 6d | 2023-10-22 | 2023-10-27 | C.70.10.04.18, C.70.10.04.16 | 3d | 0d |  | HH [380.09 h]; HM [192.02 h] | S3 |

| ID | WBS | Activity | Type | Duration | Start | Finish | Predecessors | Total float | Free float | Constraint | Resources | SECTOR |
| --- | --- | --- | --- | --- | --- | --- | --- | --- | --- | --- | --- | --- |
|  | 05 | **DIQUE A3-I-03** |  |  | 2023-06-27 | 2023-11-15 |  |  |  |  |  |  |
|  | 1 | **SECTOR 1** |  |  | 2023-07-13 | 2023-10-25 |  |  |  |  |  |  |
|  | 1 | **Tramo 1 (PK 22+750 - 23+760)** |  |  | 2023-07-13 | 2023-10-09 |  |  |  |  |  |  |
| C.70.10.05.1.11 |  | Excavación en terreno natural con equipo |  | 10d | 2023-07-13 | 2023-07-22 | C.70.01.02.25.1 | 2d | 0d |  | EXCAVACIONES [12197.4]; HH [631.83 h]; HM [407.39 h] | S2 |
| C.70.10.05.1.13 |  | Perfilado y compatación en zona de corte |  | 12d | 2023-07-23 | 2023-08-03 | C.70.10.05.1.11 | 2d | 0d |  | HH [993.72 h]; HM [451.37 h] | S2 |
| C.70.10.05.1.19 |  | Preparación de fundación cuerpo de dique | level of effort | 14d | 2023-07-23 | 2023-08-05 | C.70.10.05.1.13 SS | 2d | 0d |  | HH [86.65 h]; HM [43.48 h] | S2 |
| C.70.10.05.1.14 |  | Conformación de cuerpo de dique |  | 2d | 2023-08-04 | 2023-08-05 | C.70.10.05.1.13, C.70.10.05.1.19 FF | 2d | 0d |  | RELLENOS [810.8]; HH [167.19 h]; HM [107.03 h] | S2 |
| C.70.10.05.1.12 |  | Excavación de uña con equipo |  | 6d | 2023-08-06 | 2023-08-11 | C.70.10.05.1.14 | 2d | 0d |  | EXCAVACIONES [4276.8]; HH [265.16 h]; HM [256.61 h] | S2 |
| C.70.10.05.1.16 |  | Instalación de geotextil no tejido |  | 44d | 2023-08-12 | 2023-09-24 | C.70.10.05.1.12 | 2d | 0d |  | HH [514.48 h] | S2 |
| C.70.10.05.1.17 |  | Colocación y acomodo de roca en uña |  | 18d | 2023-08-12 | 2023-08-29 | C.70.10.05.1.16 SS | 3d | 0d |  | ENROCADOS [4276.8]; HH [1888.63 h]; HM [783.94 h] | S2 |
| C.70.10.05.1.18 |  | Colocación y acomodo de roca en talud |  | 35d | 2023-08-30 | 2023-10-03 | C.70.10.05.1.17, C.70.10.05.1.16 FF | 3d | 0d |  | HH [3488.68 h]; HM [1281.56 h]; ENROCADOS [5695.8] | S2 |
| C.70.10.05.1.15 |  | Conformación de corona de dique |  | 6d | 2023-10-04 | 2023-10-09 | C.70.10.05.1.18, C.70.10.05.1.16 | 32d | 13d |  | HH [418.55 h]; HM [211.45 h] | S2 |
|  | 2 | **Tramo 2 (PK 23+760 - 24+350)** |  |  | 2023-09-08 | 2023-10-25 |  |  |  |  |  |  |
| C.70.10.05.1.20 |  | Excavación en terreno natural con equipo |  | 5d | 2023-09-08 | 2023-09-12 | C.70.10.05.1.11 | 2d | 0d | as late as possible | EXCAVACIONES [5525.6]; HH [286.23 h]; HM [184.56 h] |  |
| C.70.10.05.1.22 |  | Perfilado y compactación en zona de corte |  | 7d | 2023-09-13 | 2023-09-19 | C.70.10.05.1.20, C.70.10.05.1.13 | 2d | 0d | as late as possible | HM [240.41 h]; HH [529.28 h] |  |
| C.70.10.05.1.28 |  | Preparación de fundación cuerpo de dique | level of effort | 8d | 2023-09-13 | 2023-09-20 | C.70.10.05.1.22 SS | 2d | 0d |  | HH [44.93 h]; HM [22.55 h] |  |
| C.70.10.05.1.23 |  | Conformación de cuerpo de dique |  | 1d | 2023-09-20 | 2023-09-20 | C.70.10.05.1.22, C.70.10.05.1.28 FF, C.70.10.05.1.14 | 2d | 0d | as late as possible | RELLENOS [548.6]; HH [113.12 h]; HM [72.42 h] |  |
| C.70.10.05.1.21 |  | Excavación de uña con equipo |  | 4d | 2023-09-21 | 2023-09-24 | C.70.10.05.1.23, C.70.10.05.1.12 | 2d | 0d | as late as possible | EXCAVACIONES [2217.6]; HH [137.49 h]; HM [133.06 h] |  |
| C.70.10.05.1.25 |  | Instalación de geotextil no tejido |  | 23d | 2023-09-25 | 2023-10-17 | C.70.10.05.1.21, C.70.10.05.1.16 | 2d | 0d | as late as possible | HH [264.8 h] |  |
| C.70.10.05.1.26 |  | Colocación y acomodo de roca en uña |  | 10d | 2023-09-25 | 2023-10-04 | C.70.10.05.1.25 SS, C.70.10.05.1.17 | 2d | 0d | as late as possible | ENROCADOS [2217.6]; HH [979.29 h]; HM [406.49 h] |  |
| C.70.10.05.1.27 |  | Colocación y acomodo de roca en talud |  | 18d | 2023-10-05 | 2023-10-22 | C.70.10.05.1.26, C.70.10.05.1.25 FF, C.70.10.05.1.18 | 2d | 0d | as late as possible | ENROCADOS [2925.1]; HH [1791.62 h]; HM [658.15 h] |  |
| C.70.10.05.1.24 |  | Conformación de corona de dique |  | 3d | 2023-10-23 | 2023-10-25 | C.70.10.05.1.25, C.70.10.05.1.27, C.70.10.05.1.15 | 19d |  |  | HH [216.74 h]; HM [109.49 h] |  |
|  | 2 | **SECTOR 2** |  |  | 2023-06-27 | 2023-11-15 |  |  |  |  |  |  |
| C.70.10.05.2.11 |  | Excavación en terreno natural con equipo |  | 13d | 2023-06-27 | 2023-07-09 | C.70.01.02.26 | 0d |  |  | EXCAVACIONES [16797.4]; HH [870.11 h]; HM [561.03 h] | S1 |
| C.70.10.05.2.13 |  | Perfilado y compatación en zona de corte |  | 21d | 2023-07-10 | 2023-07-30 | C.70.10.05.2.11 | 0d |  |  | HH [1680.56 h]; HM [763.35 h] | S1 |
| C.70.10.05.2.19 |  | Preparación de fundación cuerpo de dique | level of effort | 29d | 2023-07-10 | 2023-08-07 | C.70.10.05.2.13 SS | 0d |  |  | HH [147.63 h]; HM [74.08 h] | S1 |
| C.70.10.05.2.14 |  | Conformación de cuerpo de dique |  | 8d | 2023-07-31 | 2023-08-07 | C.70.10.05.2.13, C.70.10.05.2.19 FF | 0d |  |  | RELLENOS [4286.7]; HH [883.92 h]; HM [565.84 h] | S1 |
| C.70.10.05.2.12 |  | Excavación de uña con equipo |  | 10d | 2023-08-08 | 2023-08-17 | C.70.10.05.2.14 | 0d |  |  | EXCAVACIONES [7286.4]; HH [451.76 h]; HM [437.18 h] | S1 |
| C.70.10.05.2.16 |  | Instalación de geotextil no tejido |  | 64d | 2023-08-18 | 2023-10-20 | C.70.10.05.2.12 | 0d |  |  | ENROCADOS [9766.68]; HH [756.92 h] | S1 |
| C.70.10.05.2.17 |  | Colocación y acomodo de roca en uña |  | 30d | 2023-08-18 | 2023-09-16 | C.70.10.05.2.16 SS | 0d |  |  | ENROCADOS [7286.4]; HH [3217.67 h]; HM [1335.6 h] | S1 |
| C.70.10.05.2.18 |  | Colocación y acomodo de roca en talud |  | 50d | 2023-09-17 | 2023-11-05 | C.70.10.05.2.17, C.70.10.05.2.16 FF | 0d |  |  | HH [4914.15 h]; HM [1805.2 h] | S1 |
| C.70.10.05.2.15 |  | Conformación de corona de dique |  | 10d | 2023-11-06 | 2023-11-15 | C.70.10.05.2.18, C.70.10.05.2.16 | 0d |  |  | HH [711.77 h]; HM [359.58 h] | S1 |

| ID | WBS | Activity | Type | Duration | Start | Finish | Predecessors | Total float | Free float | Resources |
| --- | --- | --- | --- | --- | --- | --- | --- | --- | --- | --- |
|  | 11 | **SUPERFICIES DE TERRAPLEN** |  |  | 2023-10-18 | 2023-10-27 |  |  |  |  |
|  | 01 | **RAMPA A3-RA-D-01** |  |  | 2023-10-18 | 2023-10-22 |  |  |  |  |
| C.70.11.01.11 |  | Excavación en terreno natural con equipo |  | 1d | 2023-10-18 | 2023-10-18 | C.70.10.02.2.15 | 19d | 0d | HH [12.86 h]; HM [8.29 h] |
| C.70.11.01.12 |  | Conformación de cuerpo de dique |  | 2d | 2023-10-19 | 2023-10-20 | C.70.11.01.11 | 19d | 0d | HH [17.65 h]; HM [9.81 h] |
| C.70.11.01.13 |  | Conformación de coronación de rampas |  | 2d | 2023-10-21 | 2023-10-22 | C.70.11.01.12 | 19d | 0d | HH [26.58 h]; HM [13.43 h] |
|  | 02 | **RAMPA A3-RA-I-01** |  |  | 2023-10-23 | 2023-10-27 |  |  |  |  |
| C.70.11.02.11 |  | Excavación en terreno natural con equipo |  | 1d | 2023-10-23 | 2023-10-23 | C.70.10.05.2.14, C.70.11.01.13 | 19d | 0d | HH [9.27 h]; HM [5.98 h] |
| C.70.11.02.12 |  | Conformación de cuerpo de dique |  | 2d | 2023-10-24 | 2023-10-25 | C.70.11.02.11 | 19d | 0d | HH [16.19 h]; HM [9 h] |
| C.70.11.02.13 |  | Conformación de coronación de rampas |  | 2d | 2023-10-26 | 2023-10-27 | C.70.11.02.12 | 19d |  | HH [22.85 h]; HM [11.55 h] |
|  | 60 | **TRABAJOS DE RENOVACIÓN** |  |  | 2023-07-28 | 2023-11-15 |  |  |  |  |
|  | 02 | **REPARACION DE SERVICIOS EXISTENTES** |  |  | 2023-07-28 | 2023-11-15 |  |  |  |  |
|  | 01 | **REPOSICION CANAL 1** |  |  | 2023-07-28 | 2023-11-08 |  |  |  |  |
|  | 01 | **MOVIMIENTO DE TIERRAS** |  |  | 2023-07-28 | 2023-11-08 |  |  |  |  |
| C.60.02.01.01.11 |  | Excavación en terreno natural con equipo |  | 8d | 2023-07-28 | 2023-08-04 | C.80.02.14, C.70.10.02.3.10, C.70.10.04.11 | 0d |  | HH [178.74 h]; HM [115.25 h] |
| C.60.02.01.01.12 |  | Relleno estructural para obras de arte con material propio |  | 26d | 2023-10-14 | 2023-11-08 | C.60.02.01.02.17 | 7d |  | HH [1461.07 h]; HM [644.73 h] |
|  | 02 | **OBRAS DE CONCRETO** |  |  | 2023-08-05 | 2023-10-14 |  |  |  |  |
| C.60.02.01.02.13 |  | Concreto - solado |  | 6d | 2023-08-05 | 2023-08-10 | C.60.02.01.01.11 | 0d |  | HH [352.7 h]; HM [43.54 h] |
| C.60.02.01.02.12 |  | Acero de refuerzo |  | 17d | 2023-08-11 | 2023-08-27 | C.60.02.01.02.13 | 0d |  | HH [4681.03 h]; HM [3020.02 h] |
| C.60.02.01.02.15 |  | Junta Water Stop | level of effort | 34d | 2023-08-11 | 2023-09-13 | C.60.02.01.02.12 SS | 0d |  | HH [328.65 h] |
| C.60.02.01.02.11 |  | Encofrado recto |  | 17d | 2023-08-28 | 2023-09-13 | C.60.02.01.02.12, C.60.02.01.02.15 FF | 0d |  | HH [6427.77 h]; HM [2472.02 h] |
| C.60.02.01.02.14 |  | Concreto canal |  | 13d | 2023-09-14 | 2023-09-26 | C.60.02.01.02.11 | 0d |  | HH [1739.7 h]; HM [188.66 h] |
| C.60.02.01.02.17 |  | Desencofrado |  | 17d | 2023-09-27 | 2023-10-13 | C.60.02.01.02.14 | 0d |  | HH [6427.77 h]; HM [2472.02 h] |
| C.60.02.01.02.16 |  | Mamposteria de piedra |  | 1d | 2023-10-14 | 2023-10-14 | C.60.02.01.02.17 | 0d |  | HH [27.02 h]; HM [0.46 h] |
|  | 02 | **REPOSICION CANAL 3** |  |  | 2023-10-15 | 2023-11-15 |  |  |  |  |
|  | 01 | **MOVMIENTO DE TIERRAS** |  |  | 2023-10-15 | 2023-11-15 |  |  |  |  |
| C.60.02.02.01.11 |  | Excavación en terreno natural con equipo |  | 1d | 2023-10-15 | 2023-10-15 | C.80.02.15, C.70.10.01.11, C.70.10.03.11, C.60.02.01.02.16 | 0d |  | HH [14.37 h]; HM [9.27 h] |
| C.60.02.02.01.12 |  | Relleno estructural para obras de arte con material propio |  | 2d | 2023-11-14 | 2023-11-15 | C.60.02.02.02.17 | 0d |  | HH [10.79 h]; HM [4.76 h] |

| ID | WBS | Activity | Type | Duration | Start | Finish | Predecessors | Total float | Free float | Resources |
| --- | --- | --- | --- | --- | --- | --- | --- | --- | --- | --- |
|  | 02 | **OBRAS DE CONCRETO** |  |  | 2023-10-16 | 2023-11-14 |  |  |  |  |
| C.60.02.02.02.13 |  | Concreto - solado |  | 2d | 2023-10-16 | 2023-10-17 | C.60.02.02.01.11 | 0d |  | HH [94.24 h]; HM [11.63 h] |
| C.60.02.02.02.12 |  | Malla Electrosoldada |  | 9d | 2023-10-18 | 2023-10-26 | C.60.02.02.02.13 | 0d |  | HH [123.55 h] |
| C.60.02.02.02.15 |  | Junta Water Stop | level of effort | 17d | 2023-10-18 | 2023-11-03 | C.60.02.02.02.12 SS | 0d |  | HH [212.76 h] |
| C.60.02.02.02.11 |  | Encofrado recto |  | 8d | 2023-10-27 | 2023-11-03 | C.60.02.02.02.12, C.60.02.02.02.15 FF | 0d |  | HH [1147.52 h]; HM [419.49 h] |
| C.60.02.02.02.14 |  | Concreto canal |  | 2d | 2023-11-04 | 2023-11-05 | C.60.02.02.02.11 | 0d |  | HH [164.16 h]; HM [17.8 h] |
| C.60.02.02.02.17 |  | Desencofrado |  | 8d | 2023-11-06 | 2023-11-13 | C.60.02.02.02.14 | 0d |  | HH [1147.52 h]; HM [419.49 h] |
| C.60.02.02.02.16 |  | Mamposteria de piedra |  | 1d | 2023-11-14 | 2023-11-14 | C.60.02.02.02.17 | 1d |  | HH [27.02 h]; HM [0.46 h] |
|  | 03 | **REPOSICION SIFON INOPERATIVO** |  |  | 2023-10-16 | 2023-11-15 |  |  |  |  |
| C.60.02.03.11 |  | Excavación estructural para obras de arte |  | 14d | 2023-10-16 | 2023-10-29 | C.80.02.16, C.70.10.01.11 SS, C.70.10.03.11 SS, C.60.02.02.01.11 | 0d |  | HH [321.76 h]; HM [311.39 h] |
| C.60.02.03.12 |  | Colocación de cama de arena |  | 1d | 2023-10-30 | 2023-10-30 | C.60.02.03.11 | 0d |  | HH [15.97 h]; HM [6.69 h] |
| C.60.02.03.15 |  | Tuberias HDPE |  | 2d | 2023-10-31 | 2023-11-01 | C.60.02.03.12 | 0d |  | HH [37.38 h]; HM [9.12 h] |
| C.60.02.03.21 |  | Codos HDPE |  | 2d | 2023-11-02 | 2023-11-03 | C.60.02.03.15 | 0d |  | HH [21 h] |
| C.60.02.03.14 |  | Relleno comun |  | 5d | 2023-11-04 | 2023-11-08 | C.60.02.03.21 | 0d |  | HH [84.13 h]; HM [49.22 h] |
| C.60.02.03.16 |  | Concreto - Solado |  | 1d | 2023-11-09 | 2023-11-09 | C.60.02.03.14 | 0d |  | HH [1.85 h]; HM [0.23 h] |
| C.60.02.03.20 |  | Acero de refuerzo |  | 1d | 2023-11-10 | 2023-11-10 | C.60.02.03.16 | 0d |  | HH [11.16 h]; HM [7.2 h] |
| C.60.02.03.18 |  | Encofrado |  | 1d | 2023-11-11 | 2023-11-11 | C.60.02.03.20 | 0d |  | HH [16.78 h]; HM [6.45 h] |
| C.60.02.03.17 |  | Concreto |  | 1d | 2023-11-12 | 2023-11-12 | C.60.02.03.18 | 0d |  | HH [9.45 h]; HM [1.02 h] |
| C.60.02.03.19 |  | Desencofrado |  | 1d | 2023-11-13 | 2023-11-13 | C.60.02.03.17 | 0d |  | HH [16.78 h]; HM [6.45 h] |
| C.60.02.03.13 |  | Rellno estructural para obras de arte con material propio |  | 2d | 2023-11-14 | 2023-11-15 | C.60.02.03.19 | 0d |  | HH [14.7 h]; HM [6.49 h] |
|  | 21 | **REGISTROS Y CAMARAS** |  |  | 2023-07-10 | 2023-11-14 |  |  |  |  |
|  | 01 | **CAPTACION A3-CP-23-95** |  |  | 2023-07-10 | 2023-11-14 |  |  |  |  |
|  | 01 | **MOVIMIENTO DE TIERRAS** |  |  | 2023-07-28 | 2023-11-03 |  |  |  |  |
| C.21.01.01.11 |  | Excavación estructural para obras de arte |  | 8d | 2023-07-28 | 2023-08-04 | C.21.01.04.11 SS | 1d | 0d | HH [179.07 h]; HM [173.3 h] |
| C.21.01.01.12 |  | Relleno estructural para obras de arte con material propio |  | 3d | 2023-11-01 | 2023-11-03 | C.21.01.02.13, C.21.01.04.13 SS, C.21.01.05.12 SS, C.21.01.06.12 SS | 12d |  | HH [62.73 h]; HM [60.7 h] |

| ID | WBS | Activity | Duration | Start | Finish | Predecessors | Total float | Free float | Resources |
| --- | --- | --- | --- | --- | --- | --- | --- | --- | --- |
|  | 02 | **OBRAS DE CONCRETO** |  | 2023-08-05 | 2023-08-31 |  |  |  |  |
| C.21.01.02.11 |  | Concreto - solado | 1d | 2023-08-05 | 2023-08-05 | C.21.01.01.11 | 1d | 0d | HH [36.07 h]; HM [4.45 h] |
| C.21.01.02.16 |  | Acero de refuerzo | 9d | 2023-08-06 | 2023-08-14 | C.21.01.02.11 | 1d | 0d | HH [854.9 h]; HM [551.55 h] |
| C.21.01.02.14 |  | Encofrado | 5d | 2023-08-15 | 2023-08-19 | C.21.01.02.16 | 1d | 0d | HH [163.28 h]; HM [62.79 h] |
| C.21.01.02.12 |  | Concreto - muro | 6d | 2023-08-20 | 2023-08-25 | C.21.01.02.14 | 1d | 0d | HH [376.77 h]; HM [40.86 h] |
| C.21.01.02.13 |  | Concreto Ciclopeo | 1d | 2023-08-26 | 2023-08-26 | C.21.01.02.12 | 1d | 0d | HH [52.5 h]; HM [4.2 h] |
| C.21.01.02.15 |  | Desencofrado | 5d | 2023-08-27 | 2023-08-31 | C.21.01.02.13 | 1d | 0d | HH [163.28 h]; HM [62.79 h] |
|  | 03 | **ESTRUCTURAS METALICAS** |  | 2023-11-02 | 2023-11-14 |  |  |  |  |
| C.21.01.03.11 |  | Compuerta metalica | 4d | 2023-11-02 | 2023-11-05 | C.21.01.06.19 | 1d | 0d | HH [51.5 h]; HM [25 h] |
| C.21.01.03.12 |  | Rejilla | 1d | 2023-11-06 | 2023-11-06 | C.21.01.03.11 | 1d | 0d | HH [21 h]; HM [10 h] |
| C.21.01.03.13 |  | Baranda de fierro galvanizado | 1d | 2023-11-07 | 2023-11-07 | C.21.01.03.12 | 1d | 0d | HH [2.49 h]; HM [0.6 h] |
| C.21.01.03.14 |  | Escalera tipo gato | 1d | 2023-11-08 | 2023-11-08 | C.21.01.03.13 | 1d | 0d | HH [20.75 h]; HM [5 h] |
| C.21.01.03.15 |  | Tapa metálica | 6d | 2023-11-09 | 2023-11-14 | C.21.01.03.14 | 1d |  | HH [181 h]; HM [28 h] |
|  | 04 | **TUBERIA** |  | 2023-07-10 | 2023-08-13 |  |  |  |  |
| C.21.01.04.12 |  | Excavación de zanja | 8d | 2023-07-10 | 2023-07-17 | C.70.10.05.2.11, C.70.10.02.2.11 | 1d | 0d | HH [333.01 h]; HM [163.72 h] |
| C.21.01.04.14 |  | Cama de arena | 2d | 2023-07-18 | 2023-07-19 | C.21.01.04.12 | 1d | 0d | HH [30.1 h]; HM [12.61 h] |
| C.21.01.04.23 |  | Instalación tubería | 2d | 2023-07-20 | 2023-07-21 | C.21.01.04.14 | 1d | 0d | HH [44.88 h]; HM [10.95 h] |
| C.21.01.04.15 |  | Relleno común para zanjas | 6d | 2023-07-22 | 2023-07-27 | C.21.01.04.23 | 1d | 0d | HH [231.44 h]; HM [135.41 h] |
| C.21.01.04.11 |  | Excavación estructural para obras de arte | 3d | 2023-07-28 | 2023-07-30 | C.21.01.04.15 | 1d | 0d | HH [53.34 h]; HM [41.03 h] |
| C.21.01.04.16 |  | Concreto solado - Buzones | 1d | 2023-07-31 | 2023-07-31 | C.21.01.04.11 | 94d | 0d | HH [6.65 h]; HM [0.82 h] |
| C.21.01.04.20 |  | Acero de refuerzo | 3d | 2023-08-01 | 2023-08-03 | C.21.01.04.16 | 94d | 0d | HH [70.52 h]; HM [45.5 h] |
| C.21.01.04.18 |  | Encofrado recto | 1d | 2023-08-04 | 2023-08-04 | C.21.01.04.20 | 96d | 2d | HH [21.84 h]; HM [8.4 h] |
| C.21.01.04.19 |  | Encofrado curvo | 3d | 2023-08-04 | 2023-08-06 | C.21.01.04.20 | 94d | 0d | HH [52.12 h]; HM [32.57 h] |
| C.21.01.04.17 |  | Concreto - Buzones | 1d | 2023-08-07 | 2023-08-07 | C.21.01.04.18, C.21.01.04.19 | 94d | 0d | HH [35.17 h]; HM [3.81 h] |
| C.21.01.04.21 |  | Desencofrado recto | 1d | 2023-08-08 | 2023-08-08 | C.21.01.04.17 | 96d | 2d | HH [21.84 h]; HM [8.4 h] |
| C.21.01.04.22 |  | Desencodrado curvo | 3d | 2023-08-08 | 2023-08-10 | C.21.01.04.17 | 94d | 0d | HH [52.12 h]; HM [32.57 h] |
| C.21.01.04.13 |  | Relleno estructural para obras de arte con material propio | 3d | 2023-08-11 | 2023-08-13 | C.21.01.04.21, C.21.01.04.22 | 94d | 82d | HH [36.6 h]; HM [16.15 h] |

| ID | WBS | Activity | Type | Duration | Start | Finish | Predecessors | Total float | Free float | Resources |
| --- | --- | --- | --- | --- | --- | --- | --- | --- | --- | --- |
|  | 05 | **CANALES** |  |  | 2023-09-01 | 2023-10-23 |  |  |  |  |
| C.21.01.05.11 |  | Excavación estructural para obras de arte |  | 4d | 2023-09-01 | 2023-09-04 | C.21.01.04.11 SS, C.21.01.02.15 | 1d | 0d | HH [186.73 h]; HM [180.71 h] |
| C.21.01.05.13 |  | Colocación solado |  | 2d | 2023-09-05 | 2023-09-06 | C.21.01.05.11 | 1d | 0d | HH [107.94 h]; HM [13.32 h] |
| C.21.01.05.16 |  | Acero de refuerzo |  | 10d | 2023-09-07 | 2023-09-16 | C.21.01.05.13 | 1d | 0d | HH [1769.22 h]; HM [1141.43 h] |
| C.21.01.05.18 |  | Junta Water Stop | level of effort | 22d | 2023-09-07 | 2023-09-28 | C.21.01.05.16 SS | 1d | 0d | HH [33.43 h] |
| C.21.01.05.15 |  | Encofrado |  | 12d | 2023-09-17 | 2023-09-28 | C.21.01.05.16, C.21.01.05.18 FF | 1d | 0d | HH [3523.21 h]; HM [1354.97 h] |
| C.21.01.05.14 |  | Colocación concreto |  | 8d | 2023-09-29 | 2023-10-06 | C.21.01.05.15 | 1d | 0d | HH [539.08 h]; HM [58.46 h] |
| C.21.01.05.17 |  | Desencofrado |  | 12d | 2023-10-07 | 2023-10-18 | C.21.01.05.14 | 1d | 0d | HH [3523.21 h]; HM [1354.97 h] |
| C.21.01.05.12 |  | Relleno estructural para canales |  | 5d | 2023-10-19 | 2023-10-23 | C.21.01.05.17 | 1d | 0d | HH [409.88 h]; HM [180.87 h] |
|  | 06 | **OBRAS DE DESCARGA** |  |  | 2023-10-24 | 2023-11-03 |  |  |  |  |
| C.21.01.06.11 |  | Excavación estructural para obras de arte |  | 1d | 2023-10-24 | 2023-10-24 | C.21.01.04.11 SS, C.21.01.05.12 | 1d | 0d | HH [7.88 h]; HM [7.63 h] |
| C.21.01.06.13 |  | Concreto - solado |  | 1d | 2023-10-25 | 2023-10-25 | C.21.01.06.11 | 1d | 0d | HH [2.37 h]; HM [0.29 h] |
| C.21.01.06.17 |  | Acero de refuerzo |  | 1d | 2023-10-26 | 2023-10-26 | C.21.01.06.13 | 1d | 0d | HH [9.62 h]; HM [6.21 h] |
| C.21.01.06.18 |  | Junta Water Stop | level of effort | 3d | 2023-10-26 | 2023-10-28 | C.21.01.06.17 SS | 1d | 0d | HH [33.26 h] |
| C.21.01.06.15 |  | Encofrado recto |  | 2d | 2023-10-27 | 2023-10-28 | C.21.01.06.17, C.21.01.06.18 FF | 1d | 0d | HH [41.36 h]; HM [15.91 h] |
| C.21.01.06.14 |  | Concreto canal |  | 1d | 2023-10-29 | 2023-10-29 | C.21.01.06.15 | 1d | 0d | HH [10.08 h]; HM [1.09 h] |
| C.21.01.06.16 |  | Desencofrado |  | 2d | 2023-10-30 | 2023-10-31 | C.21.01.06.14 | 12d | 0d | HH [41.36 h]; HM [15.91 h] |
| C.21.01.06.19 |  | Compuerta metalica |  | 3d | 2023-10-30 | 2023-11-01 | C.21.01.06.14 | 1d | 0d | HH [92.5 h]; HM [15 h] |
| C.21.01.06.12 |  | Relleno estructural para obras de arte con material propio |  | 3d | 2023-11-01 | 2023-11-03 | C.21.01.06.16 | 12d | 0d | HH [14.63 h]; HM [6.45 h] |
|  | 02 | **CAPTACION A3-CP-21-05** |  |  | 2023-08-13 | 2023-10-25 |  |  |  |  |
|  | 01 | **MOVIMIENTO DE TIERRAS** |  |  | 2023-08-20 | 2023-10-15 |  |  |  |  |
| C.21.02.01.11 |  | Excavación estructural para obras de arte |  | 5d | 2023-08-20 | 2023-08-24 | C.21.02.04.15 | 21d | 0d | HH [110.68 h]; HM [107.12 h] |
| C.21.02.01.12 |  | Relleno estructural para obras de arte con material propio |  | 6d | 2023-10-10 | 2023-10-15 | C.21.02.05.12 SS | 22d | 1d | HH [160.95 h]; HM [71.02 h] |
|  | 02 | **OBRAS DE CONCRETO** |  |  | 2023-08-25 | 2023-09-17 |  |  |  |  |
| C.21.02.02.11 |  | Concreto - solado |  | 1d | 2023-08-25 | 2023-08-25 | C.21.02.01.11 | 21d | 0d | HH [31.27 h]; HM [3.86 h] |
| C.21.02.02.16 |  | Acero de refuerzo |  | 7d | 2023-08-26 | 2023-09-01 | C.21.02.02.11 | 21d | 0d | HH [892.59 h]; HM [575.87 h] |
| C.21.02.02.14 |  | Encofrado |  | 5d | 2023-09-02 | 2023-09-06 | C.21.02.02.16 | 21d | 0d | HH [498.83 h]; HM [191.84 h] |
| C.21.02.02.12 |  | Concreto - muro |  | 6d | 2023-09-07 | 2023-09-12 | C.21.02.02.14 | 21d | 0d | HH [359.02 h]; HM [38.93 h] |
| C.21.02.02.13 |  | Concreto Ciclopeo |  | 1d | 2023-09-07 | 2023-09-07 | C.21.02.02.14 | 26d | 5d | HH [36.38 h]; HM [2.91 h] |
| C.21.02.02.15 |  | Desencofrado |  | 5d | 2023-09-13 | 2023-09-17 | C.21.02.02.12, C.21.02.02.13 | 21d | 0d | HH [498.83 h]; HM [191.84 h] |

| ID | WBS | Activity | Type | Duration | Start | Finish | Predecessors | Total float | Free float | Resources |
| --- | --- | --- | --- | --- | --- | --- | --- | --- | --- | --- |
|  | 03 | **ESTRUCTURAS METALICAS** |  |  | 2023-10-17 | 2023-10-25 |  |  |  |  |
| C.21.02.03.11 |  | Compuerta metalica |  | 4d | 2023-10-17 | 2023-10-20 | C.21.02.02.15, C.21.02.05.12, C.21.02.01.12 | 21d | 0d | HH [51.5 h]; HM [25 h] |
| C.21.02.03.12 |  | Rejilla |  | 1d | 2023-10-21 | 2023-10-21 | C.21.02.03.11 | 21d | 0d | HH [21 h]; HM [10 h] |
| C.21.02.03.13 |  | Baranda de fierro galvanizado |  | 1d | 2023-10-22 | 2023-10-22 | C.21.02.03.12 | 21d | 0d | HH [2.49 h]; HM [0.6 h] |
| C.21.02.03.14 |  | Escalera tipo gato |  | 1d | 2023-10-23 | 2023-10-23 | C.21.02.03.13 | 21d | 0d | HH [20.75 h]; HM [5 h] |
| C.21.02.03.15 |  | Tapa metálica |  | 2d | 2023-10-24 | 2023-10-25 | C.21.02.03.14 | 21d |  | HH [45.25 h]; HM [7 h] |
|  | 04 | **TUBERÍA** |  |  | 2023-08-13 | 2023-08-30 |  |  |  |  |
| C.21.02.04.12 |  | Excavación de zanja |  | 1d | 2023-08-13 | 2023-08-13 | C.70.10.03.11, C.70.10.01.11 | 21d | 0d | HH [16.24 h]; HM [7.98 h] |
| C.21.02.04.14 |  | Cama de arena |  | 1d | 2023-08-14 | 2023-08-14 | C.21.02.04.12 | 21d | 0d | HH [1.75 h]; HM [0.73 h] |
| C.21.02.04.23 |  | Instalación tubería |  | 1d | 2023-08-15 | 2023-08-15 | C.21.02.04.14 | 21d | 0d | HH [3.23 h]; HM [0.79 h] |
| C.21.02.04.15 |  | Relleno común para zanjas |  | 4d | 2023-08-16 | 2023-08-19 | C.21.02.04.23 | 21d | 0d | HH [16.17 h]; HM [10.19 h] |
| C.21.02.04.11 |  | Excavación estructural para obras de arte |  | 1d | 2023-08-20 | 2023-08-20 | C.21.02.04.15 | 39d | 0d | HH [13.73 h]; HM [10.56 h] |
| C.21.02.04.16 |  | Concreto solado - Buzones |  | 1d | 2023-08-21 | 2023-08-21 | C.21.02.04.11 | 39d | 0d | HH [2.75 h]; HM [0.34 h] |
| C.21.02.04.20 |  | Acero de refuerzo |  | 2d | 2023-08-22 | 2023-08-23 | C.21.02.04.16 | 39d | 0d | HH [27.02 h]; HM [17.44 h] |
| C.21.02.04.18 |  | Encofrado recto |  | 1d | 2023-08-24 | 2023-08-24 | C.21.02.04.20 | 40d | 1d | HH [7.77 h]; HM [2.99 h] |
| C.21.02.04.19 |  | Encofrado curvo |  | 2d | 2023-08-24 | 2023-08-25 | C.21.02.04.20 | 39d | 0d | HH [36.25 h]; HM [22.65 h] |
| C.21.02.04.17 |  | Concreto - Buzones |  | 1d | 2023-08-26 | 2023-08-26 | C.21.02.04.18, C.21.02.04.19 | 39d | 0d | HH [22.03 h]; HM [2.39 h] |
| C.21.02.04.21 |  | Desencofrado recto |  | 1d | 2023-08-27 | 2023-08-27 | C.21.02.04.17 | 40d | 1d | HH [7.77 h]; HM [2.99 h] |
| C.21.02.04.22 |  | Desencodrado curvo |  | 2d | 2023-08-27 | 2023-08-28 | C.21.02.04.17 | 39d | 0d | HH [36.25 h]; HM [22.65 h] |
| C.21.02.04.13 |  | Relleno estructural para obras de arte con material propio |  | 2d | 2023-08-29 | 2023-08-30 | C.21.02.04.21, C.21.02.04.22 | 39d | 18d | HH [24.94 h]; HM [11.01 h] |
|  | 05 | **CANALES** |  |  | 2023-09-18 | 2023-10-16 |  |  |  |  |
| C.21.02.05.11 |  | Excavación estructural para obras de arte |  | 7d | 2023-09-18 | 2023-09-24 | C.21.02.04.15, C.21.02.02.15, C.21.02.04.13 | 21d | 0d | HH [152.82 h]; HM [147.9 h] |
| C.21.02.05.13 |  | Colocación solado |  | 1d | 2023-09-25 | 2023-09-25 | C.21.02.05.11 | 21d | 0d | HH [24.8 h]; HM [3.06 h] |
| C.21.02.05.16 |  | Acero de refuerzo |  | 3d | 2023-09-26 | 2023-09-28 | C.21.02.05.13 | 21d | 0d | HH [547.96 h]; HM [353.52 h] |
| C.21.02.05.18 |  | Junta Water Stop | level of effort | 7d | 2023-09-26 | 2023-10-02 | C.21.02.05.16 SS | 21d | 0d | HH [8.3 h] |
| C.21.02.05.15 |  | Encofrado |  | 4d | 2023-09-29 | 2023-10-02 | C.21.02.05.16, C.21.02.05.18 FF | 21d | 0d | HH [986.63 h]; HM [379.44 h] |
| C.21.02.05.14 |  | Colocación concreto |  | 3d | 2023-10-03 | 2023-10-05 | C.21.02.05.15 | 21d | 0d | HH [143.1 h]; HM [15.52 h] |
| C.21.02.05.17 |  | Desencofrado |  | 4d | 2023-10-06 | 2023-10-09 | C.21.02.05.14 | 21d | 0d | HH [986.63 h]; HM [379.44 h] |
| C.21.02.05.12 |  | Relleno estructural para canales |  | 7d | 2023-10-10 | 2023-10-16 | C.21.02.05.17 | 21d | 0d | HH [195.1 h]; HM [86.09 h] |

| ID | WBS | Activity | Type | Duration | Start | Finish | Predecessors | Total float | Free float | Resources |
| --- | --- | --- | --- | --- | --- | --- | --- | --- | --- | --- |
|  | 03 | **RETORNO A3-OA-RE-D-21-55** |  |  | 2023-09-18 | 2023-10-25 |  |  |  |  |
|  | 01 | **MOVIMIENTO DE TIERRAS** |  |  | 2023-09-18 | 2023-10-22 |  |  |  |  |
| C.21.03.01.11 |  | Excavación estructural para obras de arte |  | 1d | 2023-09-18 | 2023-09-18 | C.70.10.01.11, C.70.10.03.11, C.21.02.02.15 | 21d | 0d | HH [20.99 h]; HM [20.32 h] |
| C.21.03.01.12 |  | Relleno estructural para obras de arte con material propio |  | 1d | 2023-10-22 | 2023-10-22 | C.21.03.02.17 | 24d |  | HH [10.46 h]; HM [4.62 h] |
|  | 02 | **OBRAS DE CONCRETO** |  |  | 2023-09-19 | 2023-10-21 |  |  |  |  |
| C.21.03.02.11 |  | Concreto - solado |  | 1d | 2023-09-19 | 2023-09-19 | C.21.03.01.11 | 21d | 0d | HH [16.14 h]; HM [1.99 h] |
| C.21.03.02.15 |  | Acero de refuerzo |  | 16d | 2023-09-20 | 2023-10-05 | C.21.03.02.11 | 21d | 0d | HH [1073.28 h]; HM [692.44 h] |
| C.21.03.02.16 |  | Junta Water Stop | level of effort | 22d | 2023-09-20 | 2023-10-11 | C.21.03.02.15 SS | 21d | 0d | HH [33.33 h] |
| C.21.03.02.14 |  | Encofrado |  | 6d | 2023-10-06 | 2023-10-11 | C.21.03.02.15, C.21.03.02.16 FF | 21d | 0d | HH [199.58 h]; HM [76.76 h] |
| C.21.03.02.12 |  | Concreto |  | 2d | 2023-10-12 | 2023-10-13 | C.21.03.02.14 | 23d | 2d | HH [141.23 h]; HM [15.32 h] |
| C.21.03.02.13 |  | Concreto Ciclopeo |  | 4d | 2023-10-12 | 2023-10-15 | C.21.03.02.14 | 21d | 0d | HH [349.62 h]; HM [27.97 h] |
| C.21.03.02.17 |  | Desencofrado |  | 6d | 2023-10-16 | 2023-10-21 | C.21.03.02.12, C.21.03.02.13 | 21d | 0d | HH [199.58 h]; HM [76.76 h] |
|  | 03 | **ESTRUCTURAS METALICAS** |  |  | 2023-10-22 | 2023-10-25 |  |  |  |  |
| C.21.03.03.11 |  | Compuerta metalica plana |  | 4d | 2023-10-22 | 2023-10-25 | C.21.03.02.17 | 21d |  | HH [154.5 h]; HM [75 h] |
| C.21.03.03.12 |  | Baranda de fierro galvanizado |  | 1d | 2023-10-22 | 2023-10-22 | C.21.03.02.17 | 24d |  | HH [8.3 h]; HM [2 h] |
|  | T | **CIERRE** |  |  | 2023-11-16 | 2023-12-02 |  |  |  |  |
|  | 20 | **DESMOVILIZACIÓN** |  |  | 2023-11-16 | 2023-12-02 |  |  |  |  |
| T.20.11 |  | Desmovilización equipos |  | 14d | 2023-11-16 | 2023-11-29 | C.90.02.04.13, C.70.02.01.03.16, C.70.02.01.03.13, C.70.02.01.02.01.11, C.70.02.01.02.02.11, C.70.02.01.01.11, C.70.02.01.01.14, C.70.02.01.01.13, C.70.02.01.01.12, C.70.10.01.15, C.70.10.02.1.15, C.70.10.02.2.15, C.70.10.02.3.14, C.70.10.03.15, C.70.10.04.15, C.70.10.05.1.15, C.70.10.05.2.15, C.70.11.01.13, C.70.11.02.13, C.60.02.01.02.16, C.60.02.02.02.16, C.60.02.03.13, C.21.01.03.15, C.21.02.03.15, C.21.03.03.12, C.21.03.03.11, C.21.03.01.12, C.60.02.01.01.12, C.60.02.02.01.12, C.21.01.01.12, C.21.01.02.15, C.70.10.05.1.24, C.70.10.03.24 | 0d |  |  |
| T.20.12 |  | Desmovilización equipos - Paisajismo |  | 3d | 2023-11-30 | 2023-12-02 | T.20.11, C.70.03.03.11, C.70.05.01.17 | 0d |  |  |

## Activity codes

| Code | Value | Meaning |
| --- | --- | --- |
| SECTOR | S1 | SECTOR 1 |
| SECTOR | S2 | SECTOR 2 |
| SECTOR | S3 | SECTOR 3 |
| SECTOR | S4 | SECTOR 4 |
| SECTOR | S5 | SECTOR 5 |
